# RECEPCION

Schedule from MS Project, 2012-11-06 to 2012-12-05.
Sa

## Calendars

- Estándar: Mon-Fri 09:00-13:00, 15:00-19:00; Sat-Sun 08:00-12:00, 13:00-17:00.

## Schedule

| ID | WBS | Task | Type | Duration | Start | Finish | Predecessors | Total slack | Free slack |
| --- | --- | --- | --- | --- | --- | --- | --- | --- | --- |
| 1 | 1 | **Remodelación de Recepción** |  | 30d | 2012-11-06 | 2012-12-05 |  | 0d |  |
| 2 | 1.1 | Inicio | milestone | 0d | 2012-11-06 | 2012-11-06 |  | 0d |  |
| 3 | 1.2 | Retiro de muebles |  | 1d | 2012-11-06 | 2012-11-06 | 2 | 31d |  |
| 4 | 1.3 | Retiro de artefactos de iluminación y A-A |  | 1d | 2012-11-06 | 2012-11-06 | 2 | 31d |  |
| 5 | 1.4 | Iluminación provisoria de obra |  | 1d | 2012-11-06 | 2012-11-06 | 2 | 31d |  |
| 6 | 1.5 | Demolición de cajón de durlock |  | 1d | 2012-11-06 | 2012-11-06 | 2 | 0d |  |
| 7 | 1.6 | Preparación de instalación de ilum en cajón de durlock |  | 1d | 2012-11-07 | 2012-11-07 | 6 | 0d |  |
| 8 | 1.7 | Armado de nuevo cajón de durlock |  | 2d | 2012-11-08 | 2012-11-09 | 7 | 0d |  |
| 9 | 1.8 | Desmonte de cielorraso modular |  | 1d | 2012-11-09 | 2012-11-09 | 8FS-1d | 0d |  |
| 10 | 1.9 | Retiro de escombros en volquete |  | 1d | 2012-11-10 | 2012-11-10 | 9 | 26d | 25d |
| 11 | 1.10 | Preparación de intalaciones varias en cielorraso modular |  | 3d | 2012-11-10 | 2012-11-12 | 9 | 0d |  |
| 12 | 1.11 | Reparación de cielorraso de durlock y apertura de huecos p/artefactos |  | 2d | 2012-11-10 | 2012-11-11 | 9 | 25d | 24d |
| 13 | 1.12 | Armado de cielorraso modular |  | 3d | 2012-11-12 | 2012-11-14 | 11FS-1d | 0d |  |
| 14 | 1.13 | Armado de Instalaciones en Cielorraso Modular y continuo |  | 2d | 2012-11-15 | 2012-11-16 | 13 | 0d |  |
| 15 | 1.14 | Electricidad y cable estructurado para recepción y TV |  | 1d | 2012-11-15 | 2012-11-15 | 13 | 19d | 18d |
| 16 | 1.15 | Retiro de zócalos existentes |  | 1d | 2012-11-15 | 2012-11-15 | 13 | 19d | 18d |
| 17 | 1.16 | Preparación de cielorrasos y peredes |  | 3d | 2012-11-17 | 2012-11-19 | 14 | 0d |  |
| 18 | 1.17 | Pintura de cielorrasos y tabiques |  | 4d | 2012-11-19 | 2012-11-22 | 17FS-1d | 0d |  |
| 19 | 1.18 | Colocación de artefactos de ilum. |  | 1d | 2012-11-23 | 2012-11-23 | 18 | 12d |  |
| 20 | 1.19 | Pulido y vitrificado de piso de marmol |  | 10d | 2012-11-23 | 2012-12-02 | 18 | 0d |  |
| 21 | 1.20 | Retoques de pintura |  | 1d | 2012-12-03 | 2012-12-03 | 20 | 1d | 0d |
| 22 | 1.21 | Preparado para colocación de papel decorativo |  | 1d | 2012-12-03 | 2012-12-03 | 21FS-1d | 1d | 0d |
| 23 | 1.22 | Colocación de papel decorativo |  | 2d | 2012-12-03 | 2012-12-04 | 22FS-1d | 1d |  |
| 24 | 1.23 | Colocación para soportes de TV |  | 1d | 2012-12-04 | 2012-12-04 | 22 | 1d |  |
| 25 | 1.24 | Revestimientos de madera en paredes |  | 3d | 2012-12-03 | 2012-12-05 | 20 | 0d |  |
| 26 | 1.25 | Colocación de zócalos |  | 1d | 2012-12-03 | 2012-12-03 | 20 | 2d |  |
| 27 | 1.26 | Colocación de cortinas |  | 1d | 2012-12-03 | 2012-12-03 | 20 | 2d |  |
| 28 | 1.27 | Muebles, Banners, Gráfica en puerta |  | 1d | 2012-12-03 | 2012-12-03 | 20 | 1d | 0d |
| 29 | 1.28 | Limpieza |  | 1d | 2012-12-04 | 2012-12-04 | 28, 6, 8, 9, 10, 12, 16, 17, 18, 20, 21, 15 | 1d | 0d |
| 30 | 1.29 | Final | milestone | 0d | 2012-12-04 | 2012-12-04 | 29 | 1d |  |
